# Maybank2U UPASS Project Schedule

Schedule from MS Project, 2013-07-08 to 2014-04-21.
Lenovo

## Calendars

- Standard: Mon-Fri 08:00-12:00, 13:00-17:00; Sat-Sun off. Exceptions (off unless hours are given): 2013-08-08 to 2013-08-09 (Puasa), 2013-08-31 (Merdeka), 2013-09-16 (National Day), 2013-09-17 (Company Day), 2013-11-05 (Alwal Muharam), 2013-12-25 (Christmas), 2014-01-01 (New Year).

## Resources

| Resource |
| --- |
| Agrobank |
| Penril |
| Penril/Agrobank |
| Shu |
| Vincent |
| Kar Yan |
| Danniell |
| Hadi |
| Moein |
| Alwi |
| Khairul |
| Rizah |

## Schedule

| ID | WBS | Task | Type | Duration | Start | Finish | Predecessors | Total slack | Constraint |
| --- | --- | --- | --- | --- | --- | --- | --- | --- | --- |
| 1 | 1 | **PROJECT PLANNING** |  | 21d | 2013-07-08 | 2013-08-05 |  | 0d |  |
| 2 | 1.1 | **Requirement Study** |  | 15d | 2013-07-08 | 2013-07-26 |  | 0d |  |
| 3 | 1.1.1 | Current LDAP System study |  | 5d | 2013-07-08 | 2013-07-12 |  | 0d |  |
| 4 | 1.1.2 | Integration Study and Clarification |  | 5d | 2013-07-15 | 2013-07-19 | 3 | 0d | start no earlier than 2012-08-06 |
| 5 | 1.1.3 | Load Test LDAP for Benchmark |  | 5d | 2013-07-22 | 2013-07-26 | 4 | 0d |  |
| 6 | 1.1.4 | UPASS Administration Module Requirement Study |  | 10d | 2013-07-15 | 2013-07-26 | 3 | 0d |  |
| 7 | 1.1.5 | Requirement Sign off | milestone | 0d | 2013-07-26 | 2013-07-26 | 6 | 0d |  |
| 8 | 1.2 | Project Planning Finalization |  | 5d | 2013-07-29 | 2013-08-02 | 2 | 0d |  |
| 9 | 1.3 | Project Kick-off |  | 1d | 2013-08-05 | 2013-08-05 | 8 | 0d |  |
| 10 | 2 | **PROJECT EXECUTION** |  | 178d | 2013-08-06 | 2014-04-21 | 1 | 0d |  |
| 11 | 2.1 | **UPASS Implementation** |  | 20d | 2013-08-06 | 2013-09-04 |  | 0d |  |
| 12 | 2.1.1 | Maybank2U Integration to UPASS Customization |  | 20d | 2013-08-06 | 2013-09-04 |  | 151d |  |
| 13 | 2.1.2 | UPASS Administration Development |  | 20d | 2013-08-06 | 2013-09-04 |  | 0d |  |
| 14 | 2.2 | Deployment to SIT |  | 5d | 2013-09-05 | 2013-09-11 | 13, 11 | 0d |  |
| 15 | 2.3 | SIT |  | 15d | 2013-09-12 | 2013-10-04 | 14 | 0d |  |
| 16 | 2.4 | UPASS Load Test |  | 10d | 2013-09-12 | 2013-09-27 | 14 | 146d |  |
| 17 | 2.5 | SIT Sign-off | milestone | 0d | 2013-10-04 | 2013-10-04 | 15 | 0d |  |
| 18 | 2.6 | UAT |  | 10d | 2013-10-07 | 2013-10-18 | 17 | 0d |  |
| 19 | 2.7 | UAT Sign-off | milestone | 0d | 2013-10-18 | 2013-10-18 | 18 | 0d |  |
| 20 | 2.8 | **Migration Plan** |  | 6d | 2013-10-21 | 2013-10-28 | 19 | 0d |  |
| 21 | 2.8.1 | Pre CRM |  | 5d | 2013-10-21 | 2013-10-25 |  | 0d |  |
| 22 | 2.8.2 | Migration to PROD |  | 1d | 2013-10-28 | 2013-10-28 | 21 | 0d |  |
| 23 | 2.9 | Go Production - User Migration | milestone | 0d | 2013-10-28 | 2013-10-28 | 20 | 0d | start no earlier than 2013-07-11 |
| 24 | 2.10 | User Migration Period |  | 120d | 2013-10-29 | 2014-04-17 | 23 | 0d |  |
| 25 | 2.11 | Production - Decommission LDAP Process |  | 1d | 2014-04-18 | 2014-04-18 | 24 | 0d |  |
| 26 | 2.12 | Production - End-to-End Encryption Enablement |  | 1d | 2014-04-21 | 2014-04-21 | 25 | 0d |  |
| 27 | 2.13 | Go Production - End-to-End Encryption | milestone | 0d | 2014-04-21 | 2014-04-21 | 26 | 0d |  |

Notes:
- 4: Agrobank/Penril
- 18: Agrobank
- 19: Agrobank
- 20: Penril
- 23: Agrobank
